# Implementación de una metodología que permita una movilidad ágil en el Peaje Puente Amarillo

Schedule from MS Project, 2021-05-10 to 2022-04-25, status date 2021-11-07, costs in $, A marks actual dates.

## Calendars

- Calendario Proyecto Peaje: Mon-Fri 09:00-13:00, 15:00-19:00; Sat-Sun off. Exceptions (off unless hours are given): 2021-05-17 (Festivo Día de la Ascensión de Cristo), 2021-06-07 (Festivo Corpus Christi), 2021-06-14 (Festivo Día del Sagrado Corazón), 2021-07-05 (Festivo San Pedro y San Pablo), 2021-07-20 (Festivo Día de la Independencia de Colombia), 2021-08-07 (Festivo Batalla de Boyacá), 2021-08-16 (Festivo Día de la Asunción de la Virgen María), 2021-10-18 (Festivo Día de la Raza), 2021-11-01 (Festivo Día de Todos los Santos), 2021-11-15 (Festivo Independencia de Cartagena), 2021-12-08 (Festivo Día de la Inmaculada Concepción), 2021-12-25 (Festivo Navidad), 2022-01-01 (Año Nuevo), 2022-01-10 (Día de los Reyes Magos), 2022-03-21 (Día de San José), 2022-04-14 (Jueves Santo), 2022-04-15 (Viernes Santo).

## Resources

| Resource | Group | Unit | Rate |
| --- | --- | --- | --- |
| Gerente del Proyecto | Dirección |  | 39525.8 |
| Auditor de Sistemas de Peaje | Asesor |  | 15360.8 |
| Subdirector Finaciero | Subdirectores |  | 22666.5 |
| Profesional Finaciero | Financiera |  | 14236.9 |
| Subdirector Técnico Operativo | Subdirectores |  | 22666.5 |
| Residente Operaciones | Operaciones |  | 19856.6 |
| Auxiliar de Ingeniería Peajes | Aforo y Recaudo |  | 9139.02 |
| Profesional de Aseguramiento y Gestión de la Calidad | Calidad |  | 14236.9 |
| Auxiliar Administrativa | Administrativa |  | 9139.02 |
| Abogado | Administrativa |  | 14236.9 |
| Asistente | Administrativa |  | 8015.07 |
| Digitador 1 | Aforo y Recaudo |  | 5815.08 |
| Digitador 2 | Aforo y Recaudo |  | 5815.08 |
| Digitador 3 | Aforo y Recaudo |  | 5815.08 |
| Inspector | Operación |  | 5815.08 |
| Conductor 1 | Administrativa |  | 8194.14 |
| Conductor 2 | Administrativa |  | 8194.14 |
| Auxiliar de Sistemas | Externo a la organización |  | 8015.07 |
| Profesional TIC | Externo a la organización |  | 15360.8 |
| Técnico Peaje | Externo a la organización |  | 9139.02 |
| Programador 1 | Externo a la organización |  | 17046.8 |
| Programador 2 | Externo a la organización |  | 17046.8 |
| Ayudante | Externo a la organización |  | 5815.08 |
| Computador | Equipos de Oficina | PC escritorio + Software lic | 5500000 |
| Portatil | Equipos de Oficina | PC portatil + Software lic | 7000000 |
| Equipos de Comunicación 2 | Comunicación | Equipos de comunicación | 4125 |
| Actualización del sistema de trafico y recaudo | TIC | Global (Hardware + Software) | 150000000 |
| Equipos de video | Aforo y Recaudo | DVR + 2 Camaras | 1365000 |
| Baño Movil 1 | Instalaciones |  | 1778 |
| Jefe de Peaje | Externo a la organización |  | 10865 |
| Capacitador | Externo a la organización |  | 8015.07 |
| Asesoría especializada externa | TIC | Asesoría | 70000000 |
| Equipos de Comunicación 1 | Comunicación | Equipos de comunicación | 4125 |
| Camioneta 1 | Vehículo |  | 27500 |
| Baño Movil 2 | Instalaciones |  | 1778 |
| Camioneta 2 | Vehículo |  | 27500 |

## Schedule

| ID | WBS | Task | Type | Duration | Start | Finish | Predecessors | Complete | Remaining | Baseline start | Baseline finish | Baseline duration | Baseline 1 start | Baseline 1 finish | Total slack | Resources | Work | Actual work | Cost | Baseline cost | Actual cost |
| --- | --- | --- | --- | --- | --- | --- | --- | --- | --- | --- | --- | --- | --- | --- | --- | --- | --- | --- | --- | --- | --- |
| 1 | 1 | RESERVA DE CONTIGENCIA | milestone | 0d | 2021-05-10 | 2021-05-10 |  |  |  | 2021-05-10 | 2021-05-10 | 0d | 2021-05-10 | 2021-05-10 | 236.18d |  |  |  | 26,503,577 | 26,503,577 |  |
| 2 | 1 | **Implementación de una metodología que permita una movilidad ágil en el Peaje Puente Amarillo** |  | 236.18d | 2021-05-10 A | 2022-04-25 |  | 56% | 104.6d | 2021-05-10 | 2022-04-25 | 236.18d | 2021-05-10 | 2022-04-25 | 0d |  | 17462h | 9048h | 509,690,965.02 | 509,690,965.02 | 158,438,154 |
| 3 | 2.1 | Inicio | milestone | 0d | 2021-05-10 A | 2021-05-10 A |  | 100% |  | 2021-05-10 | 2021-05-10 | 0d | 2021-05-10 | 2021-05-10 |  |  |  |  |  |  |  |
| 4 | 1.1 | **1.1 Planeación** |  | 123d | 2021-05-10 A | 2021-11-08 A |  | 100% |  | 2021-05-10 | 2021-11-08 | 123d | 2021-05-10 | 2021-11-08 |  |  | 8328h | 8328h | 148,187,600.4 | 148,187,600.4 | 148,187,600.4 |
| 5 | 1.1.1 | **1.1.1 Gestión y documentación** |  | 123d | 2021-05-10 A | 2021-11-08 A |  | 100% |  | 2021-05-10 | 2021-11-08 | 123d | 2021-05-10 | 2021-11-08 |  |  | 7896h | 7896h | 140,418,781.2 | 140,418,781.2 | 140,418,781.2 |
| 6 | 2.2.1.1 | Crear el Acta de Constitución del Proyecto |  | 3d | 2021-05-10 A | 2021-05-12 A | 3 | 100% |  | 2021-05-10 | 2021-05-12 | 3d | 2021-05-10 | 2021-05-12 |  | Gerente del Proyecto | 24h | 24h | 948,618 | 948,618 | 948,618 |
| 7 | 2.2.1.2 | Elaborar el Plan para la Dirección del Proyecto |  | 120d | 2021-05-13 A | 2021-11-08 A | 6 | 100% |  | 2021-05-13 | 2021-11-08 | 120d | 2021-05-13 | 2021-11-08 |  | Auditor de Sistemas de Peaje; Auxiliar Administrativa; Conductor 1; Gerente del Proyecto; Subdirector Finaciero [20%]; Subdirector Técnico Operativo; Abogado; Equipos de Comunicación 1 [1 Equipos de comunicación]; Camioneta 1 | 7872h | 7872h | 139,470,163.2 | 139,470,163.2 | 139,470,163.2 |
| 8 | 1.1.2 | **1.1.2 Estudio impacto económico** |  | 30d | 2021-05-13 A | 2021-06-28 A |  | 100% |  | 2021-05-13 | 2021-06-28 | 30d | 2021-05-13 | 2021-06-28 |  |  | 432h | 432h | 7,768,819.2 | 7,768,819.2 | 7,768,819.2 |
| 9 | 2.2.2.1 | Análisis de la cadena de valor |  | 15d | 2021-05-13 A | 2021-06-03 A | 6 | 100% |  | 2021-05-13 | 2021-06-03 | 15d | 2021-05-13 | 2021-06-03 |  | Profesional Finaciero; Subdirector Finaciero [80%] | 216h | 216h | 3,884,409.6 | 3,884,409.6 | 3,884,409.6 |
| 10 | 2.2.2.2 | Cuantificación de los impactos |  | 15d | 2021-06-04 A | 2021-06-28 A | 9 | 100% |  | 2021-06-04 | 2021-06-28 | 15d | 2021-06-04 | 2021-06-28 |  | Profesional Finaciero; Subdirector Finaciero [80%] | 216h | 216h | 3,884,409.6 | 3,884,409.6 | 3,884,409.6 |
| 11 | 1.2 | **1.2 Implementación** |  | 97.85d | 2021-11-08 | 2022-03-30 |  |  |  | 2021-11-08 | 2022-03-30 | 97.85d | 2021-11-08 | 2022-03-30 | 0d |  | 7600.85h |  | 336,009,454.93 | 336,009,454.93 |  |
| 12 | 2.3.1 | Inicio fase 1 de implementación | milestone | 0d | 2021-11-08 | 2021-11-08 | 7 |  |  | 2021-11-08 | 2021-11-08 | 0d | 2021-11-08 | 2021-11-08 | 0d |  |  |  |  |  |  |
| 13 | 2.3.2 | Inicio fase 2 de implementación | milestone | 0d | 2022-03-03 | 2022-03-03 | 29 |  |  | 2022-03-03 | 2022-03-03 | 0d | 2022-03-03 | 2022-03-03 | 0d |  |  |  |  |  |  |
| 14 | 1.2.1 | **1.2.1 Recolección y análisis de la Información vehicular** |  | 97.85d | 2021-11-09 | 2022-03-30 |  |  |  | 2021-11-09 | 2022-03-30 | 97.85d | 2021-11-09 | 2022-03-30 | 0d |  | 1832.48h |  | 26,495,661.55 | 26,495,661.55 |  |
| 15 | 1.2.1.1 | **1.2.1.1 Informe velocidades en el Tráfico del Peaje Puente Amarillo** |  | 97.85d | 2021-11-09 | 2022-03-30 |  |  |  | 2021-11-09 | 2022-03-30 | 97.85d | 2021-11-09 | 2022-03-30 | 0d |  | 986.88h |  | 15,818,801.19 | 15,818,801.19 |  |
| 16 | 2.3.3.1.1 | Recopilación de datos de tráfico Fase 1 |  | 7d | 2021-11-09 | 2021-11-18 | 7, 10, 12 |  |  | 2021-11-09 | 2021-11-18 | 7d | 2021-11-09 | 2021-11-18 | 0d | Auxiliar de Ingeniería Peajes; Conductor 1; Inspector; Gerente del Proyecto; Equipos de Comunicación 2 [1 Equipos de comunicación]; Equipos de video [1 DVR + 2 Camaras]; Equipos de Comunicación 1 [1 Equipos de comunicación]; Camioneta 1 | 392h |  | 6,876,743.44 | 6,876,743.44 |  |
| 17 | 2.3.3.1.2 | Elaboración de Informe de tráfico vehicular Fase 1 |  | 3.17d | 2021-12-01 | 2021-12-06 | 22 |  |  | 2021-12-01 | 2021-12-06 | 3.17d | 2021-12-01 | 2021-12-06 | 0d | Residente Operaciones; Gerente del Proyecto; Equipos de Comunicación 1 [1 Equipos de comunicación]; Equipos de Comunicación 2 [1 Equipos de comunicación] | 101.44h |  | 1,715,157.16 | 1,715,157.16 |  |
| 18 | 2.3.3.1.3 | Recopilación de datos de tráfico Fase 2 |  | 7d | 2022-03-03 | 2022-03-14 | 29, 32, 33, 27, 28, 13 |  |  | 2022-03-03 | 2022-03-14 | 7d | 2022-03-03 | 2022-03-14 | 0d | Auxiliar de Ingeniería Peajes; Conductor 1; Inspector; Gerente del Proyecto; Equipos de Comunicación 1 [1 Equipos de comunicación]; Equipos de Comunicación 2 [1 Equipos de comunicación]; Camioneta 1 | 392h |  | 5,511,743.44 | 5,511,743.44 |  |
| 19 | 2.3.3.1.4 | Elaboración de Informe de tráfico Fase 2 |  | 3.17d | 2022-03-25 | 2022-03-30 | 24 |  |  | 2022-03-25 | 2022-03-30 | 3.17d | 2022-03-25 | 2022-03-30 | 0d | Residente Operaciones; Gerente del Proyecto; Equipos de Comunicación 1 [1 Equipos de comunicación]; Equipos de Comunicación 2 [1 Equipos de comunicación] | 101.44h |  | 1,715,157.16 | 1,715,157.16 |  |
| 20 | 1.2.1.2 | **1.2.1.2 Tabulación de información y resultados** |  | 87.68d | 2021-11-19 | 2022-03-25 |  |  |  | 2021-11-19 | 2022-03-25 | 87.68d | 2021-11-19 | 2022-03-25 | 0d |  | 845.6h |  | 10,676,860.35 | 10,676,860.35 |  |
| 21 | 2.3.3.2.1 | Procesamiento de datos de tráfico Fase 1 |  | 6d | 2021-11-19 | 2021-11-26 | 16 |  |  | 2021-11-19 | 2021-11-26 | 6d | 2021-11-19 | 2021-11-26 | 0d | Digitador 1; Digitador 2; Digitador 3; Residente Operaciones; Gerente del Proyecto; Equipos de Comunicación 1 [1 Equipos de comunicación]; Equipos de Comunicación 2 [1 Equipos de comunicación] | 336h |  | 4,083,725.76 | 4,083,725.76 |  |
| 22 | 2.3.3.2.2 | Análisis de resultados de tráfico Fase 1 |  | 2.17d | 2021-11-29 | 2021-12-01 | 21 |  |  | 2021-11-29 | 2021-12-01 | 2.17d | 2021-11-29 | 2021-12-01 | 0d | Auditor de Sistemas de Peaje; Auxiliar de Ingeniería Peajes; Gerente del Proyecto; Equipos de Comunicación 1 [1 Equipos de comunicación]; Equipos de Comunicación 2 [1 Equipos de comunicación] | 86.8h |  | 1,254,704.42 | 1,254,704.42 |  |
| 23 | 2.3.3.2.3 | Procesamiento de datos de tráfico Fase 2 |  | 6d | 2022-03-14 | 2022-03-23 | 18 |  |  | 2022-03-14 | 2022-03-23 | 6d | 2022-03-14 | 2022-03-23 | 0d | Digitador 1; Digitador 2; Digitador 3; Residente Operaciones; Gerente del Proyecto; Equipos de Comunicación 1 [1 Equipos de comunicación]; Equipos de Comunicación 2 [1 Equipos de comunicación] | 336h |  | 4,083,725.76 | 4,083,725.76 |  |
| 24 | 2.3.3.2.4 | Análisis de resultados de tráfico Fase 2 |  | 2.17d | 2022-03-23 | 2022-03-25 | 23 |  |  | 2022-03-23 | 2022-03-25 | 2.17d | 2022-03-23 | 2022-03-25 | 0d | Auditor de Sistemas de Peaje; Auxiliar de Ingeniería Peajes; Gerente del Proyecto; Equipos de Comunicación 1 [1 Equipos de comunicación]; Equipos de Comunicación 2 [1 Equipos de comunicación] | 86.8h |  | 1,254,704.42 | 1,254,704.42 |  |

| ID | WBS | Task | Type | Duration | Start | Finish | Predecessors | Complete | Remaining | Baseline start | Baseline finish | Baseline duration | Baseline 1 start | Baseline 1 finish | Total slack | Resources | Work | Actual work | Cost | Baseline cost | Actual cost |
| --- | --- | --- | --- | --- | --- | --- | --- | --- | --- | --- | --- | --- | --- | --- | --- | --- | --- | --- | --- | --- | --- |
| 25 | 1.2.2 | **1.2.2 Capacitación y entrenamiento** |  | 61.17d | 2021-12-06 | 2022-03-03 |  |  |  | 2021-12-06 | 2022-03-03 | 61.17d | 2021-12-06 | 2022-03-03 | 0d |  | 1558.4h |  | 21,444,603.39 | 21,444,603.39 |  |
| 26 | 2.3.4.1 | Campaña de capacitación personal recaudador |  | 9d | 2022-02-04 | 2022-02-17 | 32 |  |  | 2022-02-04 | 2022-02-17 | 9d | 2022-02-04 | 2022-02-17 | 0d | Jefe de Peaje; Profesional TIC; Camioneta 1; Conductor 1 | 288h |  | 4,458,240 | 4,458,240 |  |
| 27 | 2.3.4.2 | Campaña educacional de conductores |  | 9d | 2021-12-06 | 2021-12-20 | 17 |  |  | 2021-12-06 | 2021-12-20 | 9d | 2021-12-06 | 2021-12-20 | 52.17d | Residente Operaciones; Capacitador; Equipos de Comunicación 1 [1 Equipos de comunicación]; Baño Movil 1; Baño Movil 2; Camioneta 1; Conductor 1 | 504h |  | 5,129,772.48 | 5,129,772.48 |  |
| 28 | 2.3.4.3 | Campaña de promoción para el uso de Telepeaje (Recaudo electrónico) |  | 9d | 2021-12-06 | 2021-12-20 | 17 |  |  | 2021-12-06 | 2021-12-20 | 9d | 2021-12-06 | 2021-12-20 | 52.17d | Auxiliar Administrativa; Profesional TIC [20%]; Auxiliar de Sistemas; Subdirector Técnico Operativo; Equipos de Comunicación 2 [1 Equipos de comunicación]; Camioneta 2; Conductor 2 | 446.4h |  | 5,955,256.51 | 5,955,256.51 |  |
| 29 | 2.3.4.4 | Implementar recaudadoras móviles (cangureras) |  | 10d | 2022-02-17 | 2022-03-03 | 26 |  |  | 2022-02-17 | 2022-03-03 | 10d | 2022-02-17 | 2022-03-03 | 0d | Abogado; Auxiliar Administrativa; Gerente del Proyecto; Jefe de Peaje | 320h |  | 5,901,334.4 | 5,901,334.4 |  |
| 30 | 1.2.3 | **1.2.3 Actualización a los sistemas de tráfico y recaudo** |  | 42.17d | 2021-12-06 | 2022-02-04 |  |  |  | 2021-12-06 | 2022-02-04 | 42.17d | 2021-12-06 | 2022-02-04 | 0d |  | 4209.97h |  | 288,069,189.99 | 288,069,189.99 |  |
| 31 | 2.3.5.1 | Contratar asesoría especializada para actualización del sistema de tráfico y recaudo. |  | 12.17d | 2021-12-06 | 2021-12-23 | 17 |  |  | 2021-12-06 | 2021-12-23 | 12.17d | 2021-12-06 | 2021-12-23 | 0d | Abogado; Auditor de Sistemas de Peaje; Gerente del Proyecto; Profesional TIC [80%]; Asesoría especializada externa [1 Asesoría] | 369.97h |  | 77,926,284.39 | 77,926,284.39 |  |
| 32 | 2.3.5.2 | Implementar la actualización del sistema de tráfico y recaudo. |  | 30d | 2021-12-23 | 2022-02-04 | 31 |  |  | 2021-12-23 | 2022-02-04 | 30d | 2021-12-23 | 2022-02-04 | 0d | Profesional TIC; Programador 1; Programador 2; Técnico Peaje; Ayudante; Equipos de Comunicación 2 [1 Equipos de comunicación]; Conductor 2; Camioneta 2; Actualización del sistema de trafico y recaudo [1 Global (Hardware + Software)] | 1920h |  | 175,014,616.8 | 175,014,616.8 |  |
| 33 | 2.3.5.3 | Supervisar los trabajos de actualización al sistema de tráfico y recaudo. |  | 30d | 2021-12-23 | 2022-02-04 | 32SS |  |  | 2021-12-23 | 2022-02-04 | 30d | 2021-12-23 | 2022-02-04 | 19d | Auditor de Sistemas de Peaje; Auxiliar de Ingeniería Peajes; Gerente del Proyecto; Residente Operaciones; Subdirector Técnico Operativo; Equipos de Comunicación 1 [1 Equipos de comunicación]; Camioneta 1; Conductor 1 | 1920h |  | 35,128,288.8 | 35,128,288.8 |  |
| 34 | 2.3.6 | Cierre fase de implementación | milestone | 0d | 2022-03-30 | 2022-03-30 | 19 |  |  | 2022-03-30 | 2022-03-30 | 0d | 2022-03-30 | 2022-03-30 | 0d |  |  |  |  |  |  |
| 35 | 1.3 | **1.3 Control** |  | 233.18d | 2021-05-13 A | 2022-04-25 |  | 66% | 80.36d | 2021-05-13 | 2022-04-25 | 233.18d | 2021-05-13 | 2022-04-25 | 0d |  | 1533.2h | 720h | 25,493,909.69 | 25,493,909.69 | 10,250,553.6 |
| 36 | 1.3.1 | **1.3.1 Control y seguimiento** |  | 226.18d | 2021-05-13 A | 2022-04-12 |  | 70% | 67.56d | 2021-05-13 | 2022-04-12 | 226.18d | 2021-05-13 | 2022-04-12 | 0d |  | 1293.2h | 720h | 21,294,783.29 | 21,294,783.29 | 10,250,553.6 |
| 37 | 2.4.1.1 | Verificar cumplimiento del Sistema de Gestión Integrado. |  | 120d | 2021-05-13 A | 2021-11-08 | 6 | 75% | 30d | 2021-05-13 | 2021-11-08 | 120d | 2021-05-13 | 2021-11-08 | 97.85d | Profesional de Aseguramiento y Gestión de la Calidad | 960h | 720h | 13,667,404.8 | 13,667,404.8 | 10,250,553.6 |
| 38 | 2.4.1.2 | Verificación del cumplimiento de objetivos. |  | 8.33d | 2022-03-30 | 2022-04-12 | 19, 37, 34 |  |  | 2022-03-30 | 2022-04-12 | 8.33d | 2022-03-30 | 2022-04-12 | 0d | Auditor de Sistemas de Peaje; Gerente del Proyecto; Profesional de Aseguramiento y Gestión de la Calidad; Subdirector Finaciero; Subdirector Técnico Operativo | 333.2h |  | 7,627,378.49 | 7,627,378.49 |  |
| 39 | 1.3.2 | **1.3.2 Cierre y entrega final** |  | 7d | 2022-04-12 | 2022-04-25 |  |  |  | 2022-04-12 | 2022-04-25 | 7d | 2022-04-12 | 2022-04-25 | 0d |  | 240h |  | 4,199,126.4 | 4,199,126.4 |  |
| 40 | 2.4.2.1 | Socialización de cierre del proyecto |  | 2d | 2022-04-12 | 2022-04-18 | 38 |  |  | 2022-04-12 | 2022-04-18 | 2d | 2022-04-12 | 2022-04-18 | 5d | Profesional de Aseguramiento y Gestión de la Calidad | 16h |  | 227,790.08 | 227,790.08 |  |
| 41 | 2.4.2.2 | Liberación de los recursos |  | 7d | 2022-04-12 | 2022-04-25 | 38 |  |  | 2022-04-12 | 2022-04-25 | 7d | 2022-04-12 | 2022-04-25 | 0d | Abogado; Auxiliar Administrativa; Gerente del Proyecto; Asistente | 224h |  | 3,971,336.32 | 3,971,336.32 |  |
| 42 | 2.4.3 | FIN | milestone | 0d | 2022-04-25 | 2022-04-25 | 40, 41, 1 |  |  | 2022-04-25 | 2022-04-25 | 0d | 2022-04-25 | 2022-04-25 | 0d |  |  |  |  |  |  |
